# PLANNING & PD&E (TYPE 2 CE)

Schedule from MS Project, 2017-09-21 to 2021-06-02.

## Calendars

- Standard: Mon-Fri 08:00-12:00, 13:00-17:00; Sat-Sun off.

## Schedule

| ID | WBS | Task | Type | Duration | Start | Finish | Predecessors | Total slack | Constraint | PSM Codes |
| --- | --- | --- | --- | --- | --- | --- | --- | --- | --- | --- |
| 1 | 1 | **PLANNING & PRE-PD&E ACTIVITIES** |  | 409d | 2017-09-21 | 2019-04-16 |  | 0d |  |  |
| 2 | 1.1 | SWAT Planning Meeting (May take place 6 months to 5 years before SWAT Kickoff Meeting) | milestone | 1d | 2017-09-21 | 2017-09-21 |  | 0d | start no earlier than 2017-09-21 | 746 |
| 3 | 1.2 | SWAT Strategy Meeting (6 months after the SWAT Planning Meeting when the Tentative Work Program has been submitted) |  | 1d | 2018-03-26 | 2018-03-26 | 2FS+131d | 0d |  | 770 |
| 4 | 1.3 | Assign PD&E Project Manager |  | 1d | 2018-03-27 | 2018-03-27 | 3 | 19d |  | 704 |
| 5 | 1.4 | SWAT Kickoff Meeting |  | 1d | 2018-09-20 | 2018-09-20 | 12FS+10d | 0d |  | 747 |
| 6 | 1.5 | **ETDM PROGRAMMING SCREEN** |  | 97d | 2018-04-24 | 2018-09-05 |  | 0d |  |  |
| 7 | 1.5.1 | ETDM Programming Screen PED |  | 20d | 2018-04-24 | 2018-05-21 | 3FS+20d, 4 | 0d |  |  |
| 8 | 1.5.2 | ETDM Programming Screen Purpose and Need |  | 20d | 2018-04-24 | 2018-05-21 | 3FS+20d | 0d |  |  |
| 9 | 1.5.3 | ETDM/ETAT Programing Screen Start |  | 32d | 2018-05-22 | 2018-07-04 | 4, 7, 8 | 0d |  | 700 |
| 10 | 1.5.4 | Advance Notification |  | 32d | 2018-05-22 | 2018-07-04 | 4, 7, 8 | 0d |  | 224 |
| 11 | 1.5.5 | ETDM Programming Screen Responses |  | 44d | 2018-07-05 | 2018-09-04 | 9, 10 | 0d |  |  |
| 12 | 1.5.6 | ETDM Programming Final Summary Report Published |  | 1d | 2018-09-05 | 2018-09-05 | 11 | 0d |  | 702 |
| 13 | 1.6 | **DEVELOP SCOPE AND SCHEDULE** |  | 20d | 2018-09-21 | 2018-10-18 |  | 0d |  |  |
| 14 | 1.6.1 | Initial PD&E Scope (Stage 1) and Schedule Complete |  | 20d | 2018-09-21 | 2018-10-18 | 5, 12 | 0d |  | 164 |
| 15 | 1.7 | **PROCUREMENT** |  | 128d | 2018-10-19 | 2019-04-16 |  | 0d |  |  |
| 16 | 1.7.1 | PD&E Advertisement |  | 1d | 2018-10-19 | 2018-10-19 | 14 | 0d |  | 705 |
| 17 | 1.7.2 | Procurement |  | 120d | 2018-10-22 | 2019-04-05 | 16 | 0d |  |  |
| 18 | 1.7.3 | Final PD&E Scope (Stage 3) |  | 5d | 2019-04-08 | 2019-04-12 | 17 | 0d |  | 164 |
| 19 | 1.7.4 | PD&E Contract Executed |  | 1d | 2019-04-15 | 2019-04-15 | 18 | 0d |  | 239 |
| 20 | 1.7.5 | Notice to Proceed | milestone | 1d | 2019-04-16 | 2019-04-16 | 18, 19 | 0d | start no earlier than 2016-04-01 | 234 |
| 21 | 2 | **PD&E STUDY** |  | 557d | 2019-04-16 | 2021-06-02 |  | 0d |  |  |
| 22 | 2.1 | **PROJECT MANAGEMENT** |  | 7d | 2019-04-16 | 2019-04-24 |  | 0d |  |  |
| 23 | 2.1.1 | TYPE 2 CE Start |  | 1d | 2019-04-16 | 2019-04-16 | 20FS-1d | 0d |  | 706 |
| 24 | 2.1.2 | Prepare Project Management Plan |  | 5d | 2019-04-17 | 2019-04-23 | 23 | 0d |  |  |
| 25 | 2.1.3 | Prepare QC Plan |  | 5d | 2019-04-17 | 2019-04-23 | 23 | 0d |  |  |
| 26 | 2.1.4 | Project Kickoff Meeting with FDOT |  | 1d | 2019-04-24 | 2019-04-24 | 24, 25 | 0d |  |  |

| ID | WBS | Task | Type | Duration | Start | Finish | Predecessors | Total slack | Free slack | PSM Codes |
| --- | --- | --- | --- | --- | --- | --- | --- | --- | --- | --- |
| 27 | 2.2 | **PUBLIC INVOLVEMENT** |  | 428d | 2019-04-17 | 2020-12-04 |  | 0d |  |  |
| 28 | 2.2.1 | Prepare Public Involvement Plan |  | 20d | 2019-04-17 | 2019-05-14 | 23 | 31d |  | 748 |
| 29 | 2.2.2 | Public Involvement Data Collection |  | 45d | 2019-04-25 | 2019-06-26 | 26 | 0d |  |  |
| 30 | 2.2.3 | **Prepare for Public Kickoff Meeting** |  | 47d | 2019-06-27 | 2019-08-30 |  | 0d |  | 365 |
| 31 | 2.2.3.1 | Site Review |  | 1d | 2019-06-27 | 2019-06-27 | 28, 29 | 0d |  |  |
| 32 | 2.2.3.2 | Newsletter |  | 20d | 2019-06-28 | 2019-07-25 | 31 | 0d |  |  |
| 33 | 2.2.3.3 | Prepare Newspaper/ FAR/ FDOT Website Notice |  | 20d | 2019-06-28 | 2019-07-25 | 31 | 0d |  |  |
| 34 | 2.2.3.4 | Prepare Elected/Appointed/Property Owner Letters |  | 20d | 2019-06-28 | 2019-07-25 | 31 | 0d |  |  |
| 35 | 2.2.3.5 | Presentation/Display Material Review |  | 15d | 2019-07-26 | 2019-08-15 | 34, 32, 33 | 0d |  |  |
| 36 | 2.2.3.6 | Public Kickoff Meeting | milestone | 1d | 2019-08-16 | 2019-08-16 | 66, 35, 62 | 0d |  | 292 |
| 37 | 2.2.3.7 | Public Comment Period |  | 10d | 2019-08-19 | 2019-08-30 | 36 | 0d |  |  |
| 38 | 2.2.4 | **Prepare for Public Information Meeting** |  | 83d | 2019-10-31 | 2020-02-24 |  | 0d |  | 365 |
| 39 | 2.2.4.1 | Site Review |  | 1d | 2019-10-31 | 2019-10-31 | 103FS-60d, 37 | 36d | 0d |  |
| 40 | 2.2.4.2 | Newsletter |  | 20d | 2019-11-01 | 2019-11-28 | 39 | 36d | 0d |  |
| 41 | 2.2.4.3 | Prepare Newspaper/ FAR/ FDOT Website |  | 20d | 2019-11-01 | 2019-11-28 | 39 | 36d | 0d |  |
| 42 | 2.2.4.4 | Prepare Elected/Appointed/Property Owner Letters |  | 20d | 2019-11-01 | 2019-11-28 | 39 | 36d | 0d |  |
| 43 | 2.2.4.5 | Presentation/Display Material Review |  | 15d | 2019-11-29 | 2019-12-19 | 39, 40, 41, 42 | 36d |  |  |
| 44 | 2.2.4.6 | Public Information Meeting | milestone | 1d | 2020-02-10 | 2020-02-10 | 103FS+5d, 43, 82 | 0d |  | 292 |
| 45 | 2.2.4.7 | Public Comment Period |  | 10d | 2020-02-11 | 2020-02-24 | 44 | 0d |  |  |
| 46 | 2.2.5 | **Prepare for Public Hearing** |  | 118d | 2020-06-24 | 2020-12-04 |  | 0d |  | 366 |
| 47 | 2.2.5.1 | Site Review |  | 20d | 2020-06-24 | 2020-07-21 | 45, 145FS-60d | 37d | 0d |  |
| 48 | 2.2.5.2 | Newsletter |  | 20d | 2020-07-22 | 2020-08-18 | 47 | 37d | 0d |  |
| 49 | 2.2.5.3 | Prepare Newspaper/ FAR/ FDOT Website Notice |  | 20d | 2020-07-22 | 2020-08-18 | 47 | 37d | 0d |  |
| 50 | 2.2.5.4 | Prepare Elected/Appointed/Property Owner Letters |  | 20d | 2020-07-22 | 2020-08-18 | 47 | 37d | 0d |  |
| 51 | 2.2.5.5 | Presentation/Display Material Review |  | 15d | 2020-08-19 | 2020-09-08 | 47, 48, 49, 50 | 37d |  |  |
| 52 | 2.2.5.6 | Document Available for Public Review |  | 15d | 2020-10-30 | 2020-11-19 | 51, 145FS-5d, 117, 87 | 0d |  |  |
| 53 | 2.2.5.7 | Public Hearing | milestone | 1d | 2020-11-20 | 2020-11-20 | 52, 51 | 0d |  | 262 |
| 54 | 2.2.5.8 | Public Comment Period |  | 10d | 2020-11-23 | 2020-12-04 | 53 | 0d |  |  |

| ID | WBS | Task | Duration | Start | Finish | Predecessors | Total slack | Free slack | PSM Codes |
| --- | --- | --- | --- | --- | --- | --- | --- | --- | --- |
| 55 | 2.3 | **ENGINEERING ANALYSIS** | 402d | 2019-04-17 | 2020-10-29 |  | 0d |  |  |
| 56 | 2.3.1 | **Data Collection** | 30d | 2019-04-25 | 2019-06-05 |  | 51d |  |  |
| 57 | 2.3.1.1 | Roadway Data Collection | 30d | 2019-04-25 | 2019-06-05 | 26 | 76d | 0d |  |
| 58 | 2.3.1.2 | Drainage Data Collection | 30d | 2019-04-25 | 2019-06-05 | 26 | 76d | 0d |  |
| 59 | 2.3.1.3 | Bridge Data Collection | 30d | 2019-04-25 | 2019-06-05 | 26 | 76d | 0d |  |
| 60 | 2.3.1.4 | Geotechnical Data Collection | 30d | 2019-04-25 | 2019-06-05 | 26 | 76d | 0d |  |
| 61 | 2.3.1.5 | Topographic Survey and ROW Mapping | 30d | 2019-04-25 | 2019-06-05 | 26 | 76d | 0d |  |
| 62 | 2.3.1.6 | Prepare Base Map | 30d | 2019-04-25 | 2019-06-05 | 26 | 51d |  |  |
| 63 | 2.3.2 | **Traffic Analysis** | 109d | 2019-04-17 | 2019-09-16 |  | 3d |  |  |
| 64 | 2.3.2.1 | Traffic Methodology Meeting | 1d | 2019-04-17 | 2019-04-17 | 23 | 61d | 0d |  |
| 65 | 2.3.2.2 | Traffic Methodology Memorandum | 10d | 2019-04-18 | 2019-05-01 | 64 | 61d | 58d |  |
| 66 | 2.3.2.3 | Forecasting and Analysis | 23d | 2019-04-25 | 2019-05-27 | 26 | 3d | 0d |  |
| 67 | 2.3.2.4 | Prepare Traffic Projections | 20d | 2019-05-28 | 2019-06-24 | 66 | 3d | 0d |  |
| 68 | 2.3.2.5 | Prepare Capacity Analysis | 20d | 2019-06-25 | 2019-07-22 | 67 | 3d | 0d |  |
| 69 | 2.3.2.6 | Draft Traffic Analysis Report | 20d | 2019-07-23 | 2019-08-19 | 68, 65 | 3d | 0d |  |
| 70 | 2.3.2.7 | District Review - Draft Traffic Analysis Report | 15d | 2019-08-20 | 2019-09-09 | 69 | 3d | 0d |  |
| 71 | 2.3.2.8 | Final Traffic Analysis Report | 5d | 2019-09-10 | 2019-09-16 | 70 | 3d | 0d | 757 |
| 72 | 2.3.3 | **Interchange Access Request** | 259d | 2019-04-17 | 2020-04-13 |  | 52d |  |  |
| 73 | 2.3.3.1 | Initiate IAR | 1d | 2019-04-17 | 2019-04-17 | 23 | 52d | 0d |  |
| 74 | 2.3.3.2 | Prepare MLOU | 10d | 2019-04-18 | 2019-05-01 | 73 | 52d | 0d |  |
| 75 | 2.3.3.3 | DIRC/SPO Review of MLOU | 15d | 2019-05-02 | 2019-05-22 | 74 | 52d | 0d |  |
| 76 | 2.3.3.4 | FHWA Review of MLOU | 20d | 2019-05-23 | 2019-06-19 | 75 | 52d |  |  |
| 77 | 2.3.3.5 | Develop Alternatives | 30d | 2019-09-02 | 2019-10-11 | 37, 76 | 0d |  |  |
| 78 | 2.3.3.6 | Perform Operational Analysis | 20d | 2019-10-14 | 2019-11-08 | 77 | 0d |  |  |
| 79 | 2.3.3.7 | Prepare Preliminary IAR | 20d | 2019-11-11 | 2019-12-06 | 78 | 0d |  |  |
| 80 | 2.3.3.8 | DIRC/SPO Review of Preliminary IAR | 10d | 2019-12-09 | 2019-12-20 | 79 | 0d |  |  |
| 81 | 2.3.3.9 | Comment Resolution & Update Preliminary IAR | 15d | 2019-12-23 | 2020-01-10 | 80 | 0d |  |  |
| 82 | 2.3.3.10 | FHWA Review of Preliminary IAR | 20d | 2020-01-13 | 2020-02-07 | 81 | 0d |  |  |
| 83 | 2.3.3.11 | Prepare Final IAR | 10d | 2020-02-10 | 2020-02-21 | 82 | 143d | 0d |  |
| 84 | 2.3.3.12 | DIRC/SPO Review of Final IAR | 10d | 2020-02-24 | 2020-03-06 | 83 | 143d | 0d |  |
| 85 | 2.3.3.13 | Comment Resolution & Update Final IAR | 5d | 2020-03-09 | 2020-03-13 | 84 | 143d | 0d |  |
| 86 | 2.3.3.14 | FHWA/SPO Review of IAR | 20d | 2020-03-16 | 2020-04-10 | 85 | 143d | 0d |  |
| 87 | 2.3.3.15 | Safety Operations & Engineering Approval | 1d | 2020-04-13 | 2020-04-13 | 86 | 143d |  |  |

| ID | WBS | Task | Duration | Start | Finish | Predecessors | Total slack | Free slack | PSM Codes |
| --- | --- | --- | --- | --- | --- | --- | --- | --- | --- |
| 88 | 2.3.4 | **Alternative Analysis** | 366d | 2019-06-06 | 2020-10-29 |  | 0d |  |  |
| 89 | 2.3.4.1 | Roadway Analysis | 30d | 2019-09-02 | 2019-10-11 | 57, 58, 59, 60, 61, 37 | 44d | 41d |  |
| 90 | 2.3.4.2 | Structure Analysis | 30d | 2019-06-06 | 2019-07-17 | 57, 58, 59, 60, 61 | 106d | 103d |  |
| 91 | 2.3.4.3 | Typical Sections Analysis | 30d | 2019-09-02 | 2019-10-11 | 69, 57, 58, 59, 60, 61, 62, 119, 37 | 44d | 41d |  |
| 92 | 2.3.4.4 | Complete Streets/Multi Modal Analysis | 30d | 2019-08-20 | 2019-09-30 | 69, 62, 57, 58, 59, 60, 61, 119 | 53d | 50d |  |
| 93 | 2.3.4.5 | Transit Analysis | 30d | 2019-08-20 | 2019-09-30 | 57, 58, 59, 60, 61, 69, 119 | 53d | 50d |  |
| 94 | 2.3.4.6 | Concept Development | 30d | 2019-09-17 | 2019-10-28 | 68, 71, 62, 57, 58, 59, 60, 61, 119 | 3d | 0d |  |
| 95 | 2.3.4.7 | Access Management Analysis | 30d | 2019-09-17 | 2019-10-28 | 71 | 33d | 30d |  |
| 96 | 2.3.4.8 | Drainage Analysis | 30d | 2019-10-29 | 2019-12-09 | 94 | 3d | 0d |  |
| 97 | 2.3.4.9 | Utility Coordination & Analysis | 30d | 2019-10-29 | 2019-12-09 | 94 | 3d | 0d |  |
| 98 | 2.3.4.10 | Transportation Management Plan | 30d | 2019-10-29 | 2019-12-09 | 94 | 3d | 0d |  |
| 99 | 2.3.4.11 | Railroad Coordination | 30d | 2019-10-29 | 2019-12-09 | 94 | 3d | 0d |  |
| 100 | 2.3.4.12 | Evaluation Matrix (1st Draft) | 5d | 2019-12-10 | 2019-12-16 | 91, 92, 96, 97, 99, 95, 94, 93, 119, 89, 90, 98, 120 | 3d | 0d |  |
| 101 | 2.3.4.13 | Construction Cost Estimates (LRE) | 10d | 2019-12-17 | 2019-12-30 | 100 | 15d | 12d |  |
| 102 | 2.3.4.14 | Right-of-Way Analysis | 10d | 2019-12-17 | 2019-12-30 | 100 | 15d | 12d |  |
| 103 | 2.3.4.15 | Evaluation Matrix (2nd Draft) | 5d | 2020-01-16 | 2020-01-22 | 101, 102, 121, 122, 123, 124, 125, 126 | 3d | 0d |  |
| 104 | 2.3.4.16 | Risk Management | 30d | 2020-01-23 | 2020-03-04 | 103 | 3d |  |  |
| 105 | 2.3.4.17 | Refine Alternatives (based on public input) | 10d | 2020-02-25 | 2020-03-09 | 45 | 0d |  |  |
| 106 | 2.3.4.18 | Prepare 1st Draft Engineering Reports (Drainage, Utility, Roadway Plans, ITS, Lighting, Pavement, Geotech, PER) | 24d | 2020-03-10 | 2020-04-10 | 45, 71, 103, 105, 104 | 0d |  |  |
| 107 | 2.3.4.19 | Comment Resolution & District Review - 1st DRAFT Engineering Reports | 20d | 2020-04-13 | 2020-05-08 | 106 | 0d |  |  |
| 108 | 2.3.4.20 | Update 1st Draft Engineering Reports | 10d | 2020-05-11 | 2020-05-22 | 107 | 0d |  |  |
| 109 | 2.3.4.21 | Value Engineering Study | 5d | 2020-05-25 | 2020-05-29 | 108 | 0d |  |  |
| 110 | 2.3.4.22 | Value Engineering Review | 10d | 2020-06-15 | 2020-06-26 | 109FS+10d | 0d |  | 339 |
| 111 | 2.3.4.23 | Typical Section Selection | 1d | 2020-06-29 | 2020-06-29 | 110 | 10d |  | 759 |
| 112 | 2.3.4.24 | Prepare Design Variations and Exceptions | 10d | 2020-06-29 | 2020-07-10 | 110 | 0d |  |  |
| 113 | 2.3.4.25 | Alternatives Evaluation Complete | 1d | 2020-07-13 | 2020-07-13 | 112 | 0d |  | 712 |
| 114 | 2.3.4.26 | District Review - 2nd Draft Engineering Reports (Drainage, Utility, Roadway Plans, ITS, Lighting, Pavement, Geotech, PER) | 20d | 2020-07-14 | 2020-08-10 | 111, 113, 112 | 0d |  |  |
| 115 | 2.3.4.27 | OEM Engineering Review | 23d | 2020-08-11 | 2020-09-10 | 114 | 0d |  | 772 |
| 116 | 2.3.4.28 | District Prepare Responses | 12d | 2020-09-11 | 2020-09-28 | 115 | 0d |  | 773 |
| 117 | 2.3.4.29 | OEM/District Comment Resolution | 23d | 2020-09-29 | 2020-10-29 | 116 | 0d |  | 774 |

| ID | WBS | Task | Duration | Start | Finish | Predecessors | Total slack | Free slack | PSM Codes |
| --- | --- | --- | --- | --- | --- | --- | --- | --- | --- |
| 118 | 2.4 | **ENVIRONMENTAL ANALYSIS** | 330d | 2019-04-25 | 2020-07-29 |  | 37d |  |  |
| 119 | 2.4.1 | Environmental GIS Data Collection | 15d | 2019-04-25 | 2019-05-15 | 26 | 91d | 68d |  |
| 120 | 2.4.2 | Environmental GIS Desktop Analysis | 30d | 2019-10-29 | 2019-12-09 | 119, 94 | 3d | 0d |  |
| 121 | 2.4.3 | Data Collection & CRAS | 22d | 2019-12-17 | 2020-01-15 | 100 | 3d | 0d |  |
| 122 | 2.4.4 | Data Collection & Noise Analysis | 22d | 2019-12-17 | 2020-01-15 | 100, 71 | 3d | 0d |  |
| 123 | 2.4.5 | Data Collection & Contamination Screen Evaluation | 22d | 2019-12-17 | 2020-01-15 | 100 | 3d | 0d |  |
| 124 | 2.4.6 | Wetland Delineation and Evaluation | 22d | 2019-12-17 | 2020-01-15 | 100 | 3d | 0d |  |
| 125 | 2.4.7 | Data Collection & Wildlife Survey | 22d | 2019-12-17 | 2020-01-15 | 100 | 3d | 0d |  |
| 126 | 2.4.8 | Essential Fish Habitat Evaluation | 22d | 2019-12-17 | 2020-01-15 | 100 | 3d | 0d |  |
| 127 | 2.4.9 | Determination of Section 4(f) | 22d | 2019-12-17 | 2020-01-15 | 100 | 54d | 0d |  |
| 128 | 2.4.10 | Prepare 1st Draft NRE Report | 22d | 2020-01-16 | 2020-02-14 | 124, 125, 126 | 62d | 8d |  |
| 129 | 2.4.11 | Prepare 1st Draft CRAS | 22d | 2020-01-16 | 2020-02-14 | 121 | 62d | 8d |  |
| 130 | 2.4.12 | Prepare 1st Draft CSER | 22d | 2020-01-16 | 2020-02-14 | 123 | 62d | 8d |  |
| 131 | 2.4.13 | Prepare 1st Draft NSR | 22d | 2020-01-16 | 2020-02-14 | 122 | 62d | 8d |  |
| 132 | 2.4.14 | Prepare Draft Section 4(f) | 30d | 2020-01-16 | 2020-02-26 | 127 | 54d | 0d |  |
| 133 | 2.4.15 | District Review 1st Draft Environmental Reports (NRE, CSER, CRAS, Noise, Section 4(f)) | 20d | 2020-02-27 | 2020-03-25 | 128, 129, 130, 131, 132 | 54d | 0d |  |
| 134 | 2.4.16 | Comment Resolution & Update Draft Environmental Reports | 15d | 2020-03-26 | 2020-04-15 | 133 | 54d | 0d |  |
| 135 | 2.4.17 | OEM Review NRE | 25d | 2020-04-16 | 2020-05-20 | 134 | 54d | 0d |  |
| 136 | 2.4.18 | Finalize CRAS | 10d | 2020-04-16 | 2020-04-29 | 134 | 101d | 0d | 333 |
| 137 | 2.4.19 | Finalize NRE Report | 10d | 2020-05-21 | 2020-06-03 | 135 | 54d | 17d | 761 |
| 138 | 2.4.20 | Section 106 Effects Complete | 1d | 2020-04-30 | 2020-04-30 | 136 | 101d | 64d | 762 |
| 139 | 2.4.21 | Submit NRE to USFWS, NMFS, USACE, and FWS | 1d | 2020-06-29 | 2020-06-29 | 110, 137 | 37d | 0d |  |
| 140 | 2.4.22 | Informal USFWS Consultation Complete | 22d | 2020-06-30 | 2020-07-29 | 139 | 37d | 0d | 752 |
| 141 | 2.4.23 | Informal NMFS Consultation Complete | 22d | 2020-06-30 | 2020-07-29 | 139 | 37d | 0d | 763 |
| 142 | 2.4.24 | Prepare Conceptual Stage Relocation Plan | 20d | 2020-06-29 | 2020-07-24 | 110 | 40d | 3d |  |

| ID | WBS | Task | Type | Duration | Start | Finish | Predecessors | Total slack | Free slack | PSM Codes |
| --- | --- | --- | --- | --- | --- | --- | --- | --- | --- | --- |
| 143 | 2.5 | **FINAL ENGINEERING & TYPE 2 CE DOCUMENTATION** |  | 556d | 2019-04-17 | 2021-06-02 |  | 0d |  |  |
| 144 | 2.5.1 | Prepare DRAFT Type 2 CE for Public Availability |  | 20d | 2020-07-30 | 2020-08-26 | 110, 12, 138, 140, 141, 142, 150 | 37d | 0d |  |
| 145 | 2.5.2 | District Review Draft Environmental Document |  | 14d | 2020-08-27 | 2020-09-15 | 144 | 37d | 0d | 713 |
| 146 | 2.5.3 | Finalize Engineering & Environmental Reports |  | 10d | 2020-12-07 | 2020-12-18 | 54 | 0d |  |  |
| 147 | 2.5.4 | Finalize Section 4(f) |  | 5d | 2020-12-07 | 2020-12-11 | 54 | 5d |  | 751 |
| 148 | 2.5.5 | Finalize PD&E NSR |  | 5d | 2020-12-07 | 2020-12-11 | 54 | 5d |  | 335 |
| 149 | 2.5.6 | Finalize PER |  | 10d | 2020-12-07 | 2020-12-18 | 54 | 10d |  | 760 |
| 150 | 2.5.7 | Planning Consistency Complete |  | 1d | 2019-04-17 | 2019-04-17 | 23 | 372d | 335d | 710 |
| 151 | 2.5.8 | Prepare DRAFT Type 2 CE for OEM Signature |  | 10d | 2020-12-21 | 2021-01-01 | 54, 147, 148, 146 | 0d |  |  |
| 152 | 2.5.9 | District Review DRAFT Type 2 CE |  | 10d | 2021-01-04 | 2021-01-15 | 149, 151 | 0d |  |  |
| 153 | 2.5.10 | District Consultant Resolution |  | 1d | 2021-01-18 | 2021-01-18 | 152 | 0d |  |  |
| 154 | 2.5.11 | TYPE 2 CE OEM Initial Review |  | 23d | 2021-01-19 | 2021-02-18 | 152, 153 | 0d |  | 722 |
| 155 | 2.5.12 | TYPE 2 CE Cooperating Agency Initial Review |  | 23d | 2021-01-19 | 2021-02-18 | 152, 153 | 0d |  | 726 |
| 156 | 2.5.13 | District Prepares Responses |  | 12d | 2021-02-19 | 2021-03-08 | 154, 155 | 0d |  | 773 |
| 157 | 2.5.14 | OEM/District Comments Resolution |  | 23d | 2021-03-09 | 2021-04-08 | 156 | 0d |  | 774 |
| 158 | 2.5.15 | Type 2 CE OEM Final Review |  | 32d | 2021-04-09 | 2021-05-24 | 157 | 0d |  | 733 |
| 159 | 2.5.16 | Location Design Concept Acceptance |  | 1d | 2021-05-25 | 2021-05-25 | 158 | 0d |  | 263 |
| 160 | 2.5.17 | Location Design Concept Acceptance Public Notice | milestone | 1d | 2021-05-26 | 2021-05-26 | 158, 159 | 4d |  | 736 |
| 161 | 2.5.18 | Interchange Access Request Approval |  | 5d | 2021-05-26 | 2021-06-01 | 159, 87 | 0d |  | 765 |
| 162 | 2.5.19 | Pass the Torch Meeting |  | 1d | 2021-06-02 | 2021-06-02 | 160, 161 | 0d |  |  |
